# Voip

Schedule from MS Project, 2006-03-27 to 2006-10-09.

## Calendars

- Standardowy: Mon-Fri 09:00-13:00, 14:00-18:00; Sat-Sun off.

## Resources

| Resource |
| --- |
| Sponsor |
| Prezes |
| Komitet sterujący |
| Dyrektor IT |
| Kierownik IT |
| Executive Project Manager (klient) |
| Project Manager |
| Biuro projektu |
| Sekretarz Departamentu IT |
| Kontrola jakości |
| Firma zewnetrzna VoIP |
| Głowny Księgowy |
| Pracownicy IT |
| Telemarketerzy |
| Zarząd |
| Dział księgowości |
| Prawnik |
| Testerzy |
| Pracownicy |
| Sekretarka - niezła laska |
| Skrzynka wódki |

## Schedule

| ID | WBS | Task | Type | Duration | Start | Finish | Predecessors | Total slack | Free slack | Resources | Work |
| --- | --- | --- | --- | --- | --- | --- | --- | --- | --- | --- | --- |
| 1 | 1 | **Koncepcja** |  | 7d | 2006-03-27 | 2006-04-04 |  | 0d |  |  | 72h |
| 2 | 1.1 | Postawienie wymgań dotyczących projektu |  | 1d | 2006-03-27 | 2006-03-27 |  | 0d |  | Executive Project Manager (klient) | 8h |
| 3 | 1.2 | Burz mózgów |  | 3d | 2006-03-28 | 2006-03-30 | 2 | 0d |  | Biuro projektu | 24h |
| 4 | 1.3 | Wstępne oszacownaie kosztów |  | 3d | 2006-03-31 | 2006-04-04 | 3 | 0d |  | Głowny Księgowy | 24h |
| 5 | 1.4 | Wstępny harmonogram prac |  | 2d | 2006-03-31 | 2006-04-03 | 3 | 1d |  | Biuro projektu | 16h |
| 6 | 1.5 | Zatwierdzenie koncepcji | milestone | 0d | 2006-04-04 | 2006-04-04 | 4, 5 | 0d |  | Dyrektor IT; Prezes |  |
| 7 | 2 | **Stworzenie biznes planu** |  | 43.67d | 2006-04-05 | 2006-06-05 |  | 0d |  |  | 376h |
| 8 | 2.1 | Analiza strukóry firmy |  | 7d | 2006-04-05 | 2006-04-13 | 6 | 0d |  | Project Manager | 56h |
| 9 | 2.2 | Analiza ryzyka |  | 3d | 2006-04-05 | 2006-04-07 | 6 | 4d |  | Głowny Księgowy | 24h |
| 10 | 2.3 | Organizacja i zarządanie |  | 3d | 2006-04-14 | 2006-04-18 | 8, 9 | 0d |  | Project Manager | 24h |
| 11 | 2.4 | Plan finasowy |  | 6.67d | 2006-04-19 | 2006-04-27 | 10 | 0d |  | Dział księgowości [50%]; Project Manager [50%] | 40h |
| 12 | 2.5 | Próg rentowności |  | 2.67d | 2006-04-19 | 2006-04-21 | 11SS | 4d |  | Dział księgowości [50%]; Głowny Księgowy [50%] | 16h |
| 13 | 2.6 | Streszczenie kierownicze |  | 4d | 2006-04-27 | 2006-05-03 | 12, 11 | 0d |  | Sekretarz Departamentu IT | 32h |
| 14 | 2.7 | Akceptacja biznes palnu przez zarząd |  | 2d | 2006-05-03 | 2006-05-05 | 13 | 0d |  | Zarząd | 16h |
| 15 | 2.8 | Gotowy biznes plan | milestone | 0d | 2006-05-05 | 2006-05-05 | 14 | 0d |  | Project Manager |  |
| 16 | 2.9 | **Pozyskanie kapitału** |  | 21d | 2006-05-05 | 2006-06-05 |  | 16d |  |  | 168h |
| 17 | 2.9.1 | Rozmowy wstępne nad ustaleniem ceny i wielkości kredytu |  | 4d | 2006-05-05 | 2006-05-11 | 15 | 16d | 0d | Sponsor [50%]; Głowny Księgowy [50%] | 32h |
| 18 | 2.9.2 | Przygotowanie niezbędnych dokumentów do kredytu |  | 14d | 2006-05-11 | 2006-05-31 | 17 | 16d | 0d | Dział księgowości [50%]; Prawnik [50%] | 112h |
| 19 | 2.9.3 | Powtóne negocjacje w przypadku kiedy pojawiją się nieścisłości wynikłe z dokumentacji |  | 3d | 2006-05-31 | 2006-06-05 | 18 | 16d | 0d | Prawnik | 24h |
| 20 | 2.9.4 | Podpisanie umowy kredytowej | milestone | 0d | 2006-06-05 | 2006-06-05 | 19 | 16d |  | Głowny Księgowy; Prezes |  |
| 21 | 3 | **Firma zewnetrzna oferująca usługę instalacji VOIP - wybór** |  | 65.5d | 2006-05-05 | 2006-08-07 |  | 0d |  |  | 736h |
| 22 | 3.1 | Wstępny przegląd ofer znajdujących się na rynku |  | 6.67d | 2006-05-05 | 2006-05-16 | 15 | 0d |  | Kierownik IT [50%]; Dyrektor IT [50%] | 40h |
| 23 | 3.2 | Przeprwadzenie rozmów wstępnych |  | 5.33d | 2006-05-12 | 2006-05-19 | 22FS-2d | 0d |  | Kierownik IT [50%]; Dyrektor IT [50%] | 32h |
| 24 | 3.3 | Wybór 3 najlepszych ofert i przygotowanie przez nie kosztorysów wstępnych |  | 7d | 2006-05-19 | 2006-05-30 | 23 | 0d |  | Dyrektor IT | 56h |
| 25 | 3.4 | Wybór najlepszej oferty |  | 2d | 2006-05-30 | 2006-06-01 | 24 | 0d |  | Dyrektor IT | 16h |
| 26 | 3.5 | Przygotowanie kosztrysu szczegółowego przez firmę zewnętrzną |  | 14d | 2006-06-01 | 2006-06-21 | 25 | 0d |  | Firma zewnetrzna VoIP | 112h |
| 27 | 3.6 | Przedstawienie kosztorysu zarządowi |  | 2d | 2006-06-21 | 2006-06-23 | 26 | 0d |  | Firma zewnetrzna VoIP | 16h |
| 28 | 3.7 | Przedstawienie kosztorysu głownemy kisęgowemu |  | 2d | 2006-06-21 | 2006-06-23 | 26 | 0d |  | Firma zewnetrzna VoIP | 16h |
| 29 | 3.8 | Odzrzucenie kosztorysu |  | 1d | 2006-06-23 | 2006-06-26 | 27, 28 | 72.17d |  | Głowny Księgowy [50%]; Zarząd [50%] | 8h |
| 30 | 3.9 | Akceptacja kosztorysu |  | 2d | 2006-06-23 | 2006-06-27 | 27, 28 | 0d |  | Zarząd [50%]; Głowny Księgowy [50%] | 16h |
| 31 | 3.10 | Podpisanie umowy z firma inst. VoIP | milestone | 0d | 2006-06-27 | 2006-06-27 | 30 | 0d |  | Dyrektor IT |  |

| ID | WBS | Task | Type | Duration | Start | Finish | Predecessors | Total slack | Free slack | Resources | Work |
| --- | --- | --- | --- | --- | --- | --- | --- | --- | --- | --- | --- |
| 32 | 3.11 | **Firma zewnętrzna - przygotowanie do wdrożenia VoIP** |  | 12.5d | 2006-06-27 | 2006-07-14 |  | 0d |  |  | 168h |
| 33 | 3.11.1 | Konsultacje między działem IT a firmą oferującą usługe inst. Voip |  | 3.5d | 2006-06-27 | 2006-07-03 | 20, 31 | 0d |  | Kierownik IT [66.7%]; Pracownicy IT [66.7%]; Firma zewnetrzna VoIP [66.7%] | 56h |
| 34 | 3.11.2 | Przygotowanie haramonogramu prac wdrożeniowych |  | 5d | 2006-06-29 | 2006-07-06 | 33FS-2d | 0d |  | Firma zewnetrzna VoIP [50%]; Project Manager [50%] | 40h |
| 35 | 3.11.3 | Przygotowanie planu prac budowlanych |  | 5d | 2006-07-06 | 2006-07-13 | 34 | 1d |  | Firma zewnetrzna VoIP | 40h |
| 36 | 3.11.4 | Przygotowanie planu rozmieszczenia użadzeń i okablowania strukturalnego |  | 4d | 2006-07-10 | 2006-07-14 | 34FS+2d | 0d |  | Firma zewnetrzna VoIP [50%]; Pracownicy IT [50%] | 32h |
| 37 | 3.12 | **Firma zewnętrzna wdrożenie** |  | 16d | 2006-07-14 | 2006-08-07 |  | 0d |  |  | 256h |
| 38 | 3.12.1 | Adaptacja istniejącej sieci na potrzeby nowej usługi |  | 6d | 2006-07-14 | 2006-07-24 | 35, 36 | 0d |  | Firma zewnetrzna VoIP | 48h |
| 39 | 3.12.2 | Adapatacja pomieszczeń |  | 10d | 2006-07-18 | 2006-08-01 | 38FS-4d | 0d |  | Firma zewnetrzna VoIP | 80h |
| 40 | 3.12.3 | Rozbudowa sieci |  | 4d | 2006-07-19 | 2006-07-25 | 38FS-3d | 5d |  | Firma zewnetrzna VoIP | 32h |
| 41 | 3.12.4 | Dodanie nowych elementów potrzebnych do ukończenia projektu |  | 8d | 2006-07-20 | 2006-08-01 | 38FS-2d | 0d |  | Firma zewnetrzna VoIP | 64h |
| 42 | 3.12.5 | Pilotażowe uruchomienie wybranych elementów sieci |  | 4d | 2006-08-01 | 2006-08-07 | 39, 40, 41 | 0d |  | Firma zewnetrzna VoIP [50%]; Pracownicy IT [50%] | 32h |
| 43 | 3.12.6 | Zakończenie fizycznych prac wdrożeniowych | milestone | 0d | 2006-08-07 | 2006-08-07 | 42 | 0d |  | Firma zewnetrzna VoIP |  |
| 44 | 4 | **Sporządzenie Dokumentacji po wdorżeniwej** |  | 14d | 2006-08-07 | 2006-08-25 |  | 0d |  |  | 208h |
| 45 | 4.1 | Dokumentacja techniczna |  | 5d | 2006-08-07 | 2006-08-14 | 43 | 9d |  | Firma zewnetrzna VoIP | 40h |
| 46 | 4.2 | Dokumantacjca księgowa |  | 7d | 2006-08-07 | 2006-08-16 | 43 | 35.67d | 34.67d | Firma zewnetrzna VoIP | 56h |
| 47 | 4.3 | Dokumentacja szkoleniowa |  | 14d | 2006-08-07 | 2006-08-25 | 43 | 0d |  | Firma zewnetrzna VoIP | 112h |
| 48 | 5 | **Szkolenia pracowników** |  | 31.67d | 2006-08-25 | 2006-10-09 |  | 0d |  |  | 432h |
| 49 | 5.1 | Plany szkoleń |  | 4d | 2006-08-25 | 2006-08-31 | 47, 45 | 0d |  | Kierownik IT [50%]; Firma zewnetrzna VoIP [50%] | 32h |
| 50 | 5.2 | Promocja nowej technologi i idei komunikacji w przedsiębiorstwie |  | 7d | 2006-08-28 | 2006-09-06 | 49FS-3d | 0d |  | Biuro projektu | 56h |
| 51 | 5.3 | Szkolenie zasadnicze |  | 7d | 2006-09-06 | 2006-09-15 | 49, 50 | 0d |  | Firma zewnetrzna VoIP | 56h |
| 52 | 5.4 | **Szkolenie administartorów** |  | 16.67d | 2006-09-12 | 2006-10-04 |  | 0d |  |  | 144h |
| 53 | 5.4.1 | Wybór osób odpowiedzilnych za sprawy wewnetrzne |  | 2.67d | 2006-09-12 | 2006-09-14 | 51FS-3d | 0d |  | Kierownik IT [50%]; Project Manager [50%] | 16h |
| 54 | 5.4.2 | Wybór osób odpowiedzilanych za pomoc użytkownikowm (help desk) |  | 2.67d | 2006-09-12 | 2006-09-14 | 51FS-3d | 0d |  | Kierownik IT [50%]; Project Manager [50%] | 16h |
| 55 | 5.4.3 | Szkolenie kierunowe |  | 14d | 2006-09-14 | 2006-10-04 | 53, 54 | 0d |  | Firma zewnetrzna VoIP | 112h |

| ID | WBS | Task | Type | Duration | Start | Finish | Predecessors | Total slack | Free slack | Resources | Work |
| --- | --- | --- | --- | --- | --- | --- | --- | --- | --- | --- | --- |
| 56 | 5.5 | **Szkolenie użytkowników** |  | 5d | 2006-09-15 | 2006-09-22 |  | 8.67d |  |  | 120h |
| 57 | 5.5.1 | Szkolenie dla telemarketerów |  | 5d | 2006-09-15 | 2006-09-22 | 51 | 8.67d |  | Firma zewnetrzna VoIP; Telemarketerzy | 80h |
| 58 | 5.5.2 | Szkolenie dla kadry kierowniczej |  | 5d | 2006-09-15 | 2006-09-22 | 51 | 8.67d |  | Firma zewnetrzna VoIP [50%]; Pracownicy [50%] | 40h |
| 59 | 5.6 | Testy końcowe potwierdzające zdobuytą wiedzę |  | 3d | 2006-10-04 | 2006-10-09 | 55, 57, 58 | 0d |  | Pracownicy IT | 24h |
| 60 | 6 | **Testy** |  | 38.67d | 2006-08-07 | 2006-09-28 |  | 1d |  |  | 328h |
| 61 | 6.1 | Plany testowania |  | 4d | 2006-08-07 | 2006-08-11 | 43 | 1d | 0d | Dyrektor IT | 32h |
| 62 | 6.2 | Wyszuknie testerów |  | 6d | 2006-08-11 | 2006-08-21 | 61 | 1d | 0d | Pracownicy IT | 48h |
| 63 | 6.3 | Wybór testerów |  | 2d | 2006-08-21 | 2006-08-23 | 62 | 1d | 0d | Kierownik IT | 16h |
| 64 | 6.4 | Testowanie |  | 14d | 2006-08-23 | 2006-09-12 | 63 | 1d | 0d | Testerzy | 112h |
| 65 | 6.5 | Wyniki testów |  | 3d | 2006-09-12 | 2006-09-15 | 64 | 1d | 0d | Dyrektor IT | 24h |
| 66 | 6.6 | Kontrola jakości |  | 5d | 2006-09-15 | 2006-09-22 | 65 | 1d | 0d | Kontrola jakości | 40h |
| 67 | 6.7 | Korekta |  | 4.67d | 2006-09-22 | 2006-09-28 | 66 | 1d | 0d | Firma zewnetrzna VoIP [50%]; Pracownicy IT | 56h |
| 68 | 6.8 | Ukończenie fazy testów | milestone | 0d | 2006-09-28 | 2006-09-28 | 67 | 1d | 0d | Dyrektor IT; Firma zewnetrzna VoIP |  |
| 69 | 7 | Opijamy (formalnie impreza zakładowa) | milestone | 0d | 2006-10-09 | 2006-10-09 | 46, 68FS+3d, 59 | 0d |  | Sekretarka - niezła laska; Skrzynka wódki |  |
